# Bauzeitenplan_S-23-0105

Schedule from MS Project, 2026-07-20 to 2026-10-09.

## Calendars

- Standard: Mon-Fri 08:00-12:00, 13:00-17:00; Sat-Sun off.

## Resources

| Resource |
| --- |
| Aarsleff |
| SDS |
| CCC |
| Michel Bau |
| HSE |

## Schedule

| ID | WBS | Task | Duration | Start | Finish | Predecessors | Total slack | Free slack | Constraint |
| --- | --- | --- | --- | --- | --- | --- | --- | --- | --- |
| 2 | 1 | **Vorbereitende Maßnahmen** | 21d | 2026-07-20 | 2026-08-17 |  | 5d |  |  |
| 3 | 1.1 | Baustelleneinrichtung | 5d | 2026-07-20 | 2026-07-24 |  | 5d | 0d | start no earlier than 2026-07-20 |
| 4 | 1.2 | **Verkehrslenkung aufbauen** | 8d | 2026-08-03 | 2026-08-12 |  | 0d |  |  |
| 5 | 1.2.1 | SA 1 | 2d | 2026-08-03 | 2026-08-04 |  | 0d |  | start no earlier than 2026-08-03 |
| 6 | 1.2.2 | SA 2 | 2d | 2026-08-05 | 2026-08-06 | 5 | 13d | 0d |  |
| 7 | 1.2.3 | SA 3 | 2d | 2026-08-07 | 2026-08-10 | 6 | 21d | 0d |  |
| 8 | 1.2.4 | SA 4 | 2d | 2026-08-11 | 2026-08-12 | 7 | 29d | 0d |  |
| 9 | 1.3 | **Reingung und TV vor Baubeginn** | 9d | 2026-08-05 | 2026-08-17 |  | 0d |  |  |
| 10 | 1.3.1 | SA 1 | 3d | 2026-08-05 | 2026-08-07 | 5 | 0d |  |  |
| 11 | 1.3.2 | SA 2 | 3d | 2026-08-07 | 2026-08-11 | 6 | 13d |  |  |
| 12 | 1.3.3 | SA 3 | 3d | 2026-08-11 | 2026-08-13 | 7 | 21d |  |  |
| 13 | 1.3.4 | SA 4 | 3d | 2026-08-13 | 2026-08-17 | 8 | 29d |  |  |
| 14 | 1.4 | **Äußere Vorflut aufbauen** | 8d | 2026-08-05 | 2026-08-14 |  | 1d |  |  |
| 15 | 1.4.1 | SA 1 | 2d | 2026-08-05 | 2026-08-06 | 5 | 6d |  |  |
| 16 | 1.4.2 | SA 2 | 2d | 2026-08-07 | 2026-08-10 | 6 | 14d |  |  |
| 17 | 1.4.3 | SA 3 | 2d | 2026-08-11 | 2026-08-12 | 7 | 22d |  |  |
| 18 | 1.4.4 | SA 4 | 2d | 2026-08-13 | 2026-08-14 | 8 | 30d |  |  |
| 19 | 2 | **Schlauchlining** | 45d | 2026-08-10 | 2026-10-09 |  | 0d |  |  |
| 20 | 2.1 | EB 1.1 | 5d | 2026-08-10 | 2026-08-14 | 5, 10, 31, 15 | 0d |  |  |
| 21 | 2.2 | EB 1.2 | 5d | 2026-08-17 | 2026-08-21 | 5, 10, 31, 20, 15 | 0d |  |  |
| 22 | 2.3 | EB 2.1 | 5d | 2026-08-24 | 2026-08-28 | 6, 11, 16, 32, 21 | 0d |  |  |
| 23 | 2.4 | EB 2.2 | 5d | 2026-08-31 | 2026-09-04 | 6, 11, 16, 32, 22 | 0d |  |  |
| 24 | 2.5 | EB 3.1 | 5d | 2026-09-07 | 2026-09-11 | 7, 12, 17, 33, 23 | 0d |  |  |
| 25 | 2.6 | EB 3.2 | 5d | 2026-09-14 | 2026-09-18 | 7, 12, 17, 33, 24 | 0d |  |  |
| 26 | 2.7 | EB 4.1 | 5d | 2026-09-21 | 2026-09-25 | 8, 13, 18, 34, 25 | 0d |  |  |
| 27 | 2.8 | EB 4.2 | 5d | 2026-09-28 | 2026-10-02 | 8, 13, 18, 34, 26 | 0d |  |  |
| 28 | 2.9 | EB 4.3 | 5d | 2026-10-05 | 2026-10-09 | 8, 13, 18, 34, 27 | 0d |  |  |

| ID | WBS | Task | Duration | Start | Finish | Predecessors | Total slack |
| --- | --- | --- | --- | --- | --- | --- | --- |
| 29 | 3 | **Tiefbau** | 5d | 2026-07-27 | 2026-07-31 |  | 5d |
| 30 | 3.1 | **Pumpensumpf für innere Vorflut herstellen** | 5d | 2026-07-27 | 2026-07-31 |  | 5d |
| 31 | 3.1.1 | SA 1 | 5d | 2026-07-27 | 2026-07-31 | 3 | 5d |
| 32 | 3.1.2 | SA 2 | 5d | 2026-07-27 | 2026-07-31 | 3 | 15d |
| 33 | 3.1.3 | SA 3 | 5d | 2026-07-27 | 2026-07-31 | 3 | 25d |
| 34 | 3.1.4 | SA 4 | 5d | 2026-07-27 | 2026-07-31 | 3 | 35d |
